# Project Gantt Documentation

Schedule from MS Project, 2004-04-12 to 2004-07-29, costs in $.
MYK Inc

## Calendars

- Standard: Mon-Fri 08:00-12:00, 13:00-17:00; Sat-Sun off.

## Resources

| Resource | Rate |
| --- | --- |
| Mantacore |  |
| Suezette Chin | 65 |
| Phil Bock | 65 |
| Paul Gillis | 65 |
| Michael Kasa | 65 |
| Telus Install |  |
| Telus Test 1 |  |
| Telus Test 2 |  |
| Telust Test Final |  |
| NAIT IST |  |
| NAIT Legal |  |
| NAIT Program |  |
| NAIT Corporate |  |
| Mantatacore Submission |  |
| NAIT IST 2 |  |
| NAIT IST 3 |  |
| NAIT IST 4 |  |
| Telus Test Final |  |
| Shipper |  |
| Mantacore Sumbission |  |

## Schedule

| ID | Task | Type | Duration | Start | Finish | Predecessors | Total slack | Free slack | Constraint | Resources | Work | Cost |
| --- | --- | --- | --- | --- | --- | --- | --- | --- | --- | --- | --- | --- |
| 1 | Analysis Phase | milestone | 0d | 2004-04-12 | 2004-04-12 |  | 8.2d | 0d | start no earlier than 2004-04-12 | Mantatacore Submission; NAIT Corporate |  |  |
| 2 | Create NAIT Questionaires |  | 4d | 2004-04-12 | 2004-04-15 | 1 | 8.2d | 0d |  | Suezette Chin; Phil Bock; Paul Gillis; Michael Kasa | 128h | 8,320 |
| 3 | Schedule NAIT Corporate Interviews |  | 0.2d | 2004-04-16 | 2004-04-16 | 1, 2 | 8.2d | 0d |  | Suezette Chin | 1.6h | 104 |
| 4 | Schedle NAIT IST Interviews |  | 0.2d | 2004-04-16 | 2004-04-16 | 3, 1 | 8.2d | 0d |  | Suezette Chin | 1.6h | 104 |
| 5 | Schedule NAIT Program Interviews |  | 0.2d | 2004-04-16 | 2004-04-16 | 1, 4 | 8.2d | 0d |  | Suezette Chin | 1.6h | 104 |
| 6 | Schedule NAITSA Program Interviews |  | 0.2d | 2004-04-16 | 2004-04-16 | 5, 1 | 8.2d | 0d |  | Suezette Chin | 1.6h | 104 |
| 7 | Complete NAIT Corporate Interviews |  | 2d | 2004-04-16 | 2004-04-20 | 2, 3, 6 | 8.2d | 0d |  | Suezette Chin; Michael Kasa | 32h | 2,080 |
| 8 | Complete NAIT IST Interviews |  | 2d | 2004-04-20 | 2004-04-22 | 7, 2, 4 | 8.2d | 0d |  | Suezette Chin; Michael Kasa | 32h | 2,080 |
| 9 | Complete NAIT Program Interviews |  | 3d | 2004-04-22 | 2004-04-27 | 8, 2, 5 | 8.2d | 0d |  | Suezette Chin; Michael Kasa | 48h | 3,120 |
| 10 | Complete NAITSA Interviews |  | 1d | 2004-04-27 | 2004-04-28 | 9, 2, 6 | 8.2d | 0d |  | Suezette Chin; Michael Kasa | 16h | 1,040 |
| 11 | Determine Current Network Design |  | 0.5d | 2004-04-16 | 2004-04-16 | 1, 2 | 11.5d | 0d |  | Paul Gillis; Phil Bock | 8h | 520 |
| 12 | Create Current Network Testing Procedures |  | 1d | 2004-04-16 | 2004-04-19 | 1, 11 | 11.5d | 0d |  | Paul Gillis; Phil Bock | 16h | 1,040 |
| 13 | Complete Current Network Testing |  | 4d | 2004-04-19 | 2004-04-23 | 12 | 11.5d | 0d |  | Phil Bock; Paul Gillis | 64h | 4,160 |
| 14 | Compile Current Network Testing |  | 2d | 2004-04-23 | 2004-04-27 | 13 | 11.5d | 3.3d |  | Phil Bock; Paul Gillis | 32h | 2,080 |
| 15 | Compile User Questionaires |  | 2d | 2004-04-28 | 2004-04-30 | 10 | 8.2d | 0d |  | Suezette Chin; Michael Kasa | 32h | 2,080 |
| 16 | Complete Analysis Phase Documentation |  | 3.5d | 2004-04-30 | 2004-05-06 | 14, 15 | 8.2d | 0d |  | Mantacore | 28h |  |
| 17 | Analysis Complete | milestone | 0d | 2004-05-06 | 2004-05-06 | 16 | 8.2d | 0d |  | Mantatacore Submission; NAIT Corporate |  |  |
| 18 | Determine Wiring Requirements |  | 1.5d | 2004-05-06 | 2004-05-07 | 17 | 8.2d | 0d |  | Phil Bock; Telus Install; Paul Gillis | 36h | 1,560 |
| 19 | Determine Naming Standards |  | 1.5d | 2004-05-07 | 2004-05-11 | 18 | 8.2d | 0d |  | Phil Bock; Paul Gillis | 24h | 1,560 |
| 20 | Deterine Access Layer Components |  | 1.5d | 2004-05-11 | 2004-05-12 | 19 | 8.2d | 0d |  | Phil Bock; Paul Gillis | 24h | 1,560 |
| 21 | Determine Distribution Later Componenets |  | 1.5d | 2004-05-12 | 2004-05-14 | 20 | 8.2d | 0d |  | Phil Bock; Paul Gillis | 24h | 1,560 |
| 22 | Determine Core Layer Components |  | 1.5d | 2004-05-14 | 2004-05-17 | 21 | 8.2d | 0d |  | Phil Bock; Paul Gillis | 24h | 1,560 |
| 23 | Test Wireless |  | 2d | 2004-05-06 | 2004-05-10 | 17 | 12.7d | 2d |  | Suezette Chin; NAIT IST | 32h | 1,040 |
| 24 | Determine Server Configurations |  | 2d | 2004-05-06 | 2004-05-10 | 17 | 10.7d | 0d |  | Michael Kasa; NAIT Program | 32h | 1,040 |
| 25 | Determine Workstation Configurations |  | 1d | 2004-05-10 | 2004-05-11 | 24 | 10.7d | 0d |  | Suezette Chin; Michael Kasa; NAIT Program | 24h | 1,040 |
| 26 | Determine Extra Components |  | 1d | 2004-05-11 | 2004-05-12 | 25 | 10.7d | 0d |  | Suezette Chin; Michael Kasa; NAIT Program | 24h | 1,040 |
| 27 | Determine Wireless Components |  | 1d | 2004-05-12 | 2004-05-13 | 23, 26 | 10.7d | 0d |  | Suezette Chin; Michael Kasa | 16h | 1,040 |
| 28 | Order Devices | milestone | 0d | 2004-05-13 | 2004-05-13 | 27 | 10.7d | 0d |  | Mantatacore Submission; NAIT Corporate |  |  |
| 29 | Order Access Layer Equip |  | 1.5d | 2004-06-03 | 2004-06-04 | 20, 28 | 0d |  | finish no earlier than 2004-06-04 | Suezette Chin; Michael Kasa | 24h | 1,560 |
| 30 | Order Dist Layer Equip |  | 0.5d | 2004-05-14 | 2004-05-14 | 21, 28 | 11.7d | 0d |  | Michael Kasa; Suezette Chin | 8h | 520 |
| 31 | Order Core Layer Equip |  | 0.5d | 2004-05-17 | 2004-05-18 | 22, 28 | 8.2d | 0d |  | Suezette Chin; Michael Kasa | 8h | 520 |
| 32 | Order Wirless |  | 0.5d | 2004-05-13 | 2004-05-13 | 27, 28 | 44.7d | 0d |  | Michael Kasa; Suezette Chin | 8h | 520 |
| 33 | Order Servers |  | 0.5d | 2004-05-13 | 2004-05-13 | 24, 28 | 54.7d |  |  | Suezette Chin; Michael Kasa | 8h | 520 |
| 34 | Order Workstations |  | 0.5d | 2004-05-13 | 2004-05-13 | 25, 28 | 54.7d |  |  | Michael Kasa; Suezette Chin | 8h | 520 |
| 35 | Order Extra |  | 0.5d | 2004-05-13 | 2004-05-13 | 26, 28 | 51.7d | 0d |  | Suezette Chin; Michael Kasa | 8h | 520 |
| 36 | Equip Ordering Complete | milestone | 0d | 2004-05-13 | 2004-05-13 | 35 | 51.7d | 0d |  | Mantatacore Submission; NAIT Corporate |  |  |
| 37 | Create Security Policy and Procedures |  | 2d | 2004-05-13 | 2004-05-17 | 36 | 51.7d | 0d |  | Suezette Chin; Michael Kasa; NAIT IST; NAIT Legal | 64h | 2,080 |
| 38 | Create Recovery Plan |  | 1d? | 2004-05-17 | 2004-05-18 | 37 | 51.7d |  |  | Suezette Chin; Michael Kasa; NAIT IST | 24h | 1,040 |
| 39 | Wiring Start | milestone | 0d | 2004-05-11 | 2004-05-11 | 19, 18, 28 | 19.2d | 0d |  | Mantatacore Submission; NAIT Corporate |  |  |
| 40 | Start Core Wiring |  | 3d | 2004-05-11 | 2004-05-14 | 39 | 19.2d | 0d |  | Telus Install | 24h |  |
| 41 | Test Core Wiring Phase 1 |  | 2d | 2004-05-14 | 2004-05-18 | 40 | 52.2d |  |  | Phil Bock; Paul Gillis; Telus Test 1 | 48h | 2,080 |
| 42 | Start Pod A Wiring |  | 3d? | 2004-05-14 | 2004-05-19 | 40 | 19.2d | 0d |  | Telus Install | 24h |  |
| 43 | Start Pod B Wiring |  | 3d? | 2004-05-19 | 2004-05-24 | 42 | 19.2d | 0d |  | Telus Install | 24h |  |
| 44 | Start Pod C Wiring |  | 3d? | 2004-05-24 | 2004-05-27 | 43 | 19.2d | 0d |  | Telus Install | 24h |  |
| 45 | Start Inst Pod Wiring |  | 3d? | 2004-05-27 | 2004-06-01 | 44 | 19.2d | 0d |  | Telus Install | 24h |  |
| 46 | Start CC Wiring |  | 3d? | 2004-06-01 | 2004-06-04 | 45 | 19.2d |  |  | Telus Install | 24h |  |
| 47 | Pod A Testing Phase 1 |  | 2d | 2004-06-18 | 2004-06-22 | 42, 65, 66, 67, 68, 69 | 0d |  |  | Phil Bock; Paul Gillis; Telus Test 1 | 48h | 2,080 |
| 48 | Pod B Testing Phase 1 |  | 2d | 2004-06-22 | 2004-06-24 | 65, 66, 67, 68, 69, 43, 47 | 0d |  |  | Phil Bock; Paul Gillis; Telus Test 1 | 48h | 2,080 |
| 49 | Pod C Testing Phase 1 |  | 2d | 2004-06-24 | 2004-06-28 | 65, 66, 67, 68, 69, 44, 48 | 0d |  |  | Phil Bock; Paul Gillis; Telus Test 1 | 48h | 2,080 |
| 50 | Pod Inst Testing Phase 1 |  | 3d | 2004-06-28 | 2004-07-01 | 65, 66, 67, 68, 69, 45, 49 | 0d |  |  | Phil Bock; Paul Gillis; Telus Test 1 | 72h | 3,120 |
| 51 | Pod CC Testing Phase 1 |  | 4d | 2004-07-01 | 2004-07-07 | 65, 66, 67, 68, 69, 46, 50 | 0d |  |  | Phil Bock; Paul Gillis; Telus Test 1 | 96h | 4,160 |
| 52 | Pod A Phase 1 Complete | milestone | 0d | 2004-06-22 | 2004-06-22 | 47 | 14d |  |  | Mantatacore Submission; NAIT Corporate |  |  |
| 53 | Pod B Phase 1 Complete | milestone | 0d | 2004-06-24 | 2004-06-24 | 48 | 14d |  |  | Mantatacore Submission; NAIT Corporate |  |  |
| 54 | Pod C Phase 1 Complete | milestone | 0d | 2004-06-28 | 2004-06-28 | 49 | 14d |  |  | Mantatacore Submission; NAIT Corporate |  |  |
| 55 | Pod Inst Phase 1 Complete | milestone | 0d | 2004-07-01 | 2004-07-01 | 50 | 13d |  |  | Mantatacore Submission; NAIT Corporate |  |  |
| 56 | Pod CC Phase 1 Complete | milestone | 0d | 2004-07-07 | 2004-07-07 | 51 | 0d |  |  | Mantatacore Submission; NAIT Corporate |  |  |
| 57 | Core Equip Ship |  | 3d | 2004-05-18 | 2004-05-21 | 31 | 8.2d | 0d |  | Shipper | 24h |  |
| 58 | Dist Equip Ship |  | 3d | 2004-05-14 | 2004-05-19 | 30 | 11.7d | 3.5d |  | Shipper | 24h |  |
| 59 | Access Equip Ship |  | 1.5d | 2004-06-07 | 2004-06-08 | 29 | 0d |  | start no earlier than 2004-06-07 | Shipper | 12h |  |
| 60 | Server Ship |  | 5d | 2004-05-10 | 2004-05-17 | 24 | 18.2d |  |  | Shipper | 40h |  |
| 61 | Workstation 1 Ship (1/5 total) |  | 5d | 2004-05-11 | 2004-05-18 | 25 | 20.2d |  |  | Shipper | 40h |  |
| 62 | Workstation 2 Ship (2/5 total) |  | 7d | 2004-05-11 | 2004-05-20 | 25 | 40.2d | 21.2d |  | Shipper | 56h |  |
| 63 | Ext Ship |  | 12d | 2004-05-12 | 2004-05-28 | 26 | 34.2d | 0d |  | Shipper | 96h |  |
| 64 | Wireless Ship |  | 5d | 2004-05-13 | 2004-05-20 | 32 | 44.7d | 10.5d |  | Shipper | 40h |  |
| 65 | Core Equip Config |  | 2d | 2004-05-21 | 2004-05-25 | 57 | 8.2d | 0d |  | Michael Kasa | 16h | 1,040 |
| 66 | Dist Equip Config |  | 2d | 2004-05-25 | 2004-05-27 | 58, 65 | 8.2d |  |  | Michael Kasa | 16h | 1,040 |
| 67 | Access Equip Config |  | 2d | 2004-06-08 | 2004-06-10 | 59, 66 | 0d |  |  | Michael Kasa | 16h | 1,040 |
| 68 | Server Config |  | 3d | 2004-06-10 | 2004-06-15 | 60, 67 | 0d |  |  | Michael Kasa; NAIT IST; NAIT IST 2 | 72h | 1,560 |
| 69 | Workstation Config 1 (1/5 total Workstations) |  | 3d | 2004-06-15 | 2004-06-18 | 61, 68 | 0d |  |  | NAIT IST; NAIT IST 2 | 48h |  |
| 70 | Workstation Config 2 (4/5 Workstations) |  | 10d | 2004-06-18 | 2004-07-02 | 62, 69 | 19d |  |  | NAIT IST; NAIT IST 3; NAIT IST 2 | 240h |  |

| ID | Task | Type | Duration | Start | Finish | Predecessors | Total slack | Free slack | Resources | Work | Cost |
| --- | --- | --- | --- | --- | --- | --- | --- | --- | --- | --- | --- |
| 71 | Ext Config |  | 5d | 2004-05-28 | 2004-06-04 | 63 | 34.2d | 0d | NAIT IST 4 | 40h |  |
| 72 | Wireless Config |  | 2d | 2004-06-04 | 2004-06-08 | 64, 71 | 34.2d | 0d | Suezette Chin; Michael Kasa | 32h | 2,080 |
| 73 | Wirless Test 1 |  | 3d | 2004-06-08 | 2004-06-11 | 72 | 34.2d | 0d | Suezette Chin; NAIT IST 4 | 48h | 1,560 |
| 74 | Wireless Test Complete | milestone | 0d | 2004-06-11 | 2004-06-11 | 73 | 34.2d |  | Mantatacore Submission; NAIT Corporate |  |  |
| 75 | Ex TroubleShooting |  | 3d | 2004-07-07 | 2004-07-12 | 56 | 0d |  | Mantacore; Telus Test 1; NAIT IST | 72h |  |
| 76 | Pod A Testing Phase 2 |  | 2d | 2004-07-12 | 2004-07-14 | 52, 75 | 0d |  | Phil Bock; Paul Gillis; Telus Test 2; NAIT IST | 64h | 2,080 |
| 77 | Pod B Testing Phase 2 |  | 2d | 2004-07-14 | 2004-07-16 | 53, 75, 76 | 0d |  | Phil Bock; Paul Gillis; Telus Test 2; NAIT IST | 64h | 2,080 |
| 78 | Pod C Testing Phase 2 |  | 2d | 2004-07-16 | 2004-07-20 | 54, 75, 77 | 0d |  | Phil Bock; Paul Gillis; Telus Test 2; NAIT IST | 64h | 2,080 |
| 79 | Pod Inst Testing Phase 2 |  | 2d | 2004-07-20 | 2004-07-22 | 55, 75, 78 | 0d |  | Phil Bock; Paul Gillis; Telus Test 2; NAIT IST | 64h | 2,080 |
| 80 | Pod CC Testing Phase 2 |  | 2d | 2004-07-22 | 2004-07-26 | 56, 75, 79 | 0d |  | Paul Gillis; Telus Test 2; Phil Bock; NAIT IST | 64h | 2,080 |
| 81 | Pod A Final Phase Complete | milestone | 0d | 2004-07-14 | 2004-07-14 | 76 | 11d |  | NAIT Corporate; Mantacore Sumbission |  |  |
| 82 | Pod B Final Phase Complete | milestone | 0d | 2004-07-16 | 2004-07-16 | 77 | 9d |  | Mantatacore Submission; NAIT Corporate |  |  |
| 83 | Pod C Final Phase Complete | milestone | 0d | 2004-07-20 | 2004-07-20 | 78 | 7d |  | Mantatacore Submission; NAIT Corporate |  |  |
| 84 | Pod Inst Final Phase Complete | milestone | 0d | 2004-07-22 | 2004-07-22 | 79 | 5d |  | Mantatacore Submission; NAIT Corporate |  |  |
| 85 | Pod CC Final Phase Complete | milestone | 0d | 2004-07-26 | 2004-07-26 | 80 | 0d |  | NAIT Corporate; Mantatacore Submission |  |  |
| 86 | ICTC Testing Phase |  | 3d | 2004-07-26 | 2004-07-29 | 85 | 0d |  | Phil Bock; Paul Gillis; Telust Test Final; NAIT IST | 96h | 3,120 |
| 87 | ICTC Testing Phase Complete | milestone | 0d | 2004-07-29 | 2004-07-29 | 86 | 0d |  | NAIT Corporate; Mantatacore Submission |  |  |
| 88 | ICTC Centre Complete Project Signoff | milestone | 0d | 2004-07-29 | 2004-07-29 | 87 | 0d |  | Mantatacore Submission; NAIT Corporate |  |  |
